# Professional_WBS_120_Activities

Schedule from MS Project, 2026-01-03 to 2026-08-15, status date 2026-07-20, costs in ریال, A marks actual dates.

## Calendars

- Standard: Mon-Thu 08:00-12:00, 13:00-17:00; Fri off; Sat-Sun 08:00-12:00, 13:00-17:00.

## Schedule

| ID | WBS | Task | Type | Duration | Start | Finish | Predecessors | Complete | Remaining | Total slack | Cost | Actual cost | Text16 |
| --- | --- | --- | --- | --- | --- | --- | --- | --- | --- | --- | --- | --- | --- |
| 1 | 1 | **پروژه احداث نیروگاه گازسوز 2000 کیلووات (CAT CG170)** |  | 193d | 2026-01-03 A | 2026-08-15 |  | 96% | 7.12d | 0d | 1,114,801.4 | 1,100,801.4 |  |
| 2 | 1.1 | شروع | milestone | 0d | 2026-01-03 A | 2026-01-03 A |  | 100% |  |  |  |  |  |
| 3 | 1.2 | **تشریفات قرارداد (contract)** |  | 122d | 2026-01-03 A | 2026-05-24 A |  | 100% |  |  |  |  |  |
| 4 | 1.2.1 | تهیه اسناد مناقصه و برگزاری تشریفات مناقصه |  | 60d | 2026-01-03 A | 2026-03-12 A | 2 | 100% |  |  |  |  | شرکت افق تأمین انرژی پارس |
| 5 | 1.2.2 | مذاکرات قراردادی و انعقاد قرارداد با پیمانکار EPC |  | 26d | 2026-03-14 A | 2026-04-12 A | 4 | 100% |  |  |  |  | شرکت افق تأمین انرژی پارس |
| 6 | 1.2.3 | انعقاد قرارداد MC |  | 1d | 2026-05-24 A | 2026-05-24 A | 5FS+35d | 100% |  |  |  |  | شرکت افق تأمین انرژی پارس |
| 7 | 1.1 | **مهندسی و طراحی (Engineering)** |  | 43.4d | 2026-04-14 A | 2026-06-03 A |  | 100% |  |  | 5,000 | 5,000 |  |
| 8 | 1.1.1 | **طراحی پایه (Basic Design)** |  | 43.4d | 2026-04-14 A | 2026-06-03 A |  | 100% |  |  | 1,000 | 1,000 |  |
| 9 | 1.1.1.1 | تهیه نقشه های جانمایی (General Layout) |  | 5d | 2026-04-14 A | 2026-05-26 A | 6 | 100% |  |  | 200 | 200 | تانیر |
| 10 | 1.1.1.2 | تهیه نمودارهای P&ID سیستم های مکانیک |  | 5d | 2026-04-18 A | 2026-05-27 A | 9 | 100% |  |  | 200 | 200 | تانیر |
| 11 | 1.1.1.3 | **طراحی تک خطی دیاگرام های برقی (SLD)** |  | 36.4d | 2026-04-22 A | 2026-06-03 A |  | 100% |  |  | 600 | 600 |  |
| 12 | 1.1.1.3.1 | آماده سازی برای طراحی تک خطی دیاگرام های برقی (SLD) |  | 6d | 2026-04-22 A | 2026-05-31 A | 10 | 100% |  |  | 300 | 300 | تانیر |
| 13 | 1.1.1.3.2 | اجرای نهایی و بازرسی طراحی تک خطی دیاگرام های برقی (SLD) |  | 6d | 2026-04-26 A | 2026-06-03 A | 12 | 100% |  |  | 300 | 300 | تانیر |
| 14 | 1.1.2 | **مهندسی تفصیلی (Detail Design)** |  | 36.9d | 2026-04-18 A | 2026-05-30 A |  | 100% |  |  | 4,000 | 4,000 |  |
| 15 | 1.3.2.1 | **مهندسی عمران و سازه** |  | 35.4d | 2026-04-18 A | 2026-05-28 A |  | 100% |  |  | 950 | 950 |  |
| 16 | 1.3.2.1.1 | **طراحی عمومی سایت** |  | 34.2d | 2026-04-18 A | 2026-05-27 A |  | 100% |  |  | 150 | 150 |  |
| 17 | 1.3.2.1.1.1 | پلان کلی سایت (Plot Plan) |  | 1d | 2026-04-18 A | 2026-05-27 A | 9 | 100% |  |  | 150 | 150 | تانیر |
| 18 | 1.3.2.1.2 | **طراحی فونداسیون‌ها** |  | 2d | 2026-04-19 A | 2026-04-20 A |  | 100% |  |  | 250 | 250 |  |
| 19 | 1.3.2.1.2.1 | فونداسیون موتور |  | 1d | 2026-04-19 A | 2026-04-19 A | 17 | 100% |  |  | 50 | 50 | تانیر |
| 20 | 1.3.2.1.2.2 | فونداسیون ترانسفورماتور |  | 1d | 2026-04-20 A | 2026-04-20 A | 19 | 100% |  |  | 50 | 50 | تانیر |
| 21 | 1.3.2.1.2.3 | فونداسیون مخازن آب و روغن |  | 1d | 2026-04-20 A | 2026-04-20 A | 19 | 100% |  |  | 50 | 50 | تانیر |
| 22 | 1.3.2.1.2.4 | فونداسیون ایرکولر |  | 1d | 2026-04-20 A | 2026-04-20 A | 19 | 100% |  |  | 50 | 50 | تانیر |
| 23 | 1.3.2.1.2.5 | فونداسیون پمپ‌ها |  | 1d | 2026-04-20 A | 2026-04-20 A | 19 | 100% |  |  | 50 | 50 | تانیر |
| 24 | 1.3.2.1.3 | **سیستم‌های زیرزمینی** |  | 33.4d | 2026-04-20 A | 2026-05-28 A |  | 100% |  |  | 200 | 200 |  |
| 25 | 1.3.2.1.3.1 | طراحی کانال کابل |  | 1d | 2026-04-20 A | 2026-05-27 A | 17 | 100% |  |  | 50 | 50 | تانیر |
| 26 | 1.3.2.1.3.2 | طراحی ترانشه لوله |  | 1d | 2026-04-21 A | 2026-05-27 A | 25 | 100% |  |  | 50 | 50 | تانیر |
| 27 | 1.3.2.1.3.3 | طراحی پایپ اسلیپر |  | 1d | 2026-04-22 A | 2026-05-27 A | 26 | 100% |  |  | 50 | 50 | تانیر |
| 28 | 1.3.2.1.3.4 | طراحی چاه‌های ارت |  | 1d | 2026-05-27 A | 2026-05-28 A | 25 | 100% |  |  | 50 | 50 | تانیر |

| ID | WBS | Task | Duration | Start | Finish | Predecessors | Complete | Cost | Actual cost | Text16 |
| --- | --- | --- | --- | --- | --- | --- | --- | --- | --- | --- |
| 29 | 1.3.2.1.4 | **ساختمان‌ها و معماری** | 32.5d | 2026-04-20 A | 2026-05-27 A |  | 100% | 200 | 200 |  |
| 30 | 1.3.2.1.4.1 | معماری سالن موتور | 1d | 2026-04-20 A | 2026-05-27 A | 17 | 100% | 50 | 50 | تانیر |
| 31 | 1.3.2.1.4.2 | معماری شلتر (نما، مقطع، جزئیات) | 1d | 2026-04-21 A | 2026-05-27 A | 30 | 100% | 50 | 50 | تانیر |
| 32 | 1.3.2.1.4.3 | ساختمان CCB / اتاق کنترل / سوئیچگی | 1d | 2026-04-21 A | 2026-05-27 A | 30 | 100% | 100 | 100 | تانیر |
| 33 | 1.3.2.1.5 | **جزئیات سازه‌ای** | 3d | 2026-04-21 A | 2026-04-23 A |  | 100% | 150 | 150 |  |
| 34 | 1.1.2.4 | نقشه سازه‌ای دودکش (Stack) | 1d | 2026-04-21 A | 2026-04-21 A | 30 | 100% | 50 | 50 | تانیر |
| 35 | 1.3.2.1.5.2 | سکوی رادیاتور | 2d | 2026-04-21 A | 2026-04-22 A | 22 | 100% | 50 | 50 | تانیر |
| 36 | 1.3.2.1.5.3 | سازه های نصب تجهیزات مکانیکی | 3d | 2026-04-21 A | 2026-04-23 A | 23 | 100% | 50 | 50 | تانیر |
| 37 | 1.3.2.2 | **مهندسی مکانیک** | 30.7d | 2026-04-22 A | 2026-05-27 A |  | 100% | 1,700 | 1,700 |  |
| 38 | 1.3.2.2.1 | **مبانی طراحی مکانیک** | 4d | 2026-04-22 A | 2026-04-26 A |  | 100% | 200 | 200 |  |
| 39 | 1.3.2.2.1.1 | شرح فرآیند | 2d | 2026-04-22 A | 2026-04-23 A | 10 | 100% | 100 | 100 | تانیر |
| 40 | 1.3.2.2.1.2 | معیارهای طراحی مکانیک | 2d | 2026-04-25 A | 2026-04-26 A | 39 | 100% | 100 | 100 | تانیر |
| 41 | 1.3.2.2.2 | **تجهیزات دوار** | 5d | 2026-04-27 A | 2026-05-02 A |  | 100% | 350 | 350 |  |
| 42 | 1.3.2.2.2.1 | مشخصات و دیتاشیت موتورهای گازسوز | 1d | 2026-04-27 A | 2026-04-27 A | 40 | 100% | 50 | 50 | تانیر |
| 43 | 1.3.2.2.2.2 | **مهندسی و خرید پمپ‌ها** | 4d | 2026-04-28 A | 2026-05-02 A |  | 100% | 300 | 300 |  |
| 44 | 1.3.2.2.2.2.1 | تهیه دیتاشیت پمپ LT Oil Feed | 1d | 2026-04-28 A | 2026-04-28 A | 42 | 100% | 50 | 50 |  |
| 45 | 1.3.2.2.2.2.2 | تهیه دیتاشیت پمپ HT Oil Feed | 1d | 2026-04-29 A | 2026-04-29 A | 44 | 100% | 50 | 50 |  |
| 46 | 1.3.2.2.2.2.3 | تهیه دیتاشیت پمپ Feed Water | 1d | 2026-04-30 A | 2026-04-30 A | 45 | 100% | 100 | 100 |  |
| 47 | 1.3.2.2.2.2.4 | تهیه دیتاشیت سایر پمپ‌ها (Utility / Service / Cooling) | 1d | 2026-05-02 A | 2026-05-02 A | 46 | 100% | 100 | 100 |  |
| 48 | 1.3.2.2.3 | **تجهیزات ثابت** | 26.7d | 2026-04-27 A | 2026-05-27 A |  | 100% | 150 | 150 |  |
| 49 | 1.3.2.2.3.1 | مشخصات مخازن | 1d | 2026-04-27 A | 2026-04-27 A | 40 | 100% | 100 | 100 | تانیر |
| 50 | 1.3.2.2.3.2 | سیستم تهویه و فن‌ها | 1d | 2026-04-27 A | 2026-05-27 A | 30, 40 | 100% | 50 | 50 | تانیر |
| 51 | 1.3.2.2.4 | **مهندسی پایپینگ** | 4d | 2026-04-28 A | 2026-05-02 A |  | 100% | 300 | 300 |  |
| 52 | 1.3.2.2.4.1 | نقشه‌های آرایش لوله (GA) | 1d | 2026-04-28 A | 2026-04-28 A | 42 | 100% | 50 | 50 | تانیر |
| 53 | 1.3.2.2.4.2 | نقشه‌های ایزومتریک | 1d | 2026-04-29 A | 2026-04-29 A | 52 | 100% | 50 | 50 | تانیر |
| 54 | 1.3.2.2.4.3 | نقشه‌های ساپورت لوله | 1d | 2026-04-30 A | 2026-04-30 A | 53 | 100% | 100 | 100 | تانیر |
| 55 | 1.3.2.2.4.4 | متره و برآورد لوله‌ها (MTO) | 1d | 2026-04-30 A | 2026-04-30 A | 53 | 100% | 50 | 50 | تانیر |
| 56 | 1.3.2.2.4.5 | عایق‌کاری و پوشش | 1d | 2026-05-02 A | 2026-05-02 A | 55 | 100% | 50 | 50 | تانیر |

| ID | WBS | Task | Duration | Start | Finish | Predecessors | Complete | Cost | Actual cost | Text16 |
| --- | --- | --- | --- | --- | --- | --- | --- | --- | --- | --- |
| 57 | 1.3.2.2.5 | **سیستم‌های جانبی** | 2d | 2026-04-29 A | 2026-04-30 A |  | 100% | 300 | 300 |  |
| 58 | 1.3.2.2.5.1 | سیستم خنک‌کاری | 1d | 2026-04-29 A | 2026-04-29 A | 42, 52 | 100% | 50 | 50 | تانیر |
| 59 | 1.3.2.2.5.2 | سیستم روغن‌کاری | 1d | 2026-04-30 A | 2026-04-30 A | 58 | 100% | 50 | 50 | تانیر |
| 60 | 1.3.2.2.5.3 | سیستم اگزاست | 1d | 2026-04-30 A | 2026-04-30 A | 58 | 100% | 50 | 50 | تانیر |
| 61 | 1.3.2.2.5.4 | سیستم هوای سالن | 1d | 2026-04-30 A | 2026-04-30 A | 58 | 100% | 150 | 150 | تانیر |
| 62 | 1.3.2.2.6 | **مهندسی فرآیند** | 4d | 2026-04-26 A | 2026-04-29 A |  | 100% | 200 | 200 |  |
| 63 | 1.3.2.2.6.1 | **طراحی فرآیند** | 4d | 2026-04-26 A | 2026-04-29 A |  | 100% | 200 | 200 |  |
| 64 | 1.3.2.2.6.1.1 | تهیه PFD | 1d | 2026-04-26 A | 2026-04-26 A |  | 100% | 50 | 50 | تانیر |
| 65 | 1.3.2.2.6.1.2 | تهیه P&ID | 1d | 2026-04-27 A | 2026-04-27 A | 64 | 100% | 50 | 50 | تانیر |
| 66 | 1.3.2.2.6.1.3 | محاسبات هیدرولیکی | 1d | 2026-04-28 A | 2026-04-28 A | 65 | 100% | 50 | 50 | تانیر |
| 67 | 1.3.2.2.6.1.4 | سایزینگ خطوط | 1d | 2026-04-29 A | 2026-04-29 A | 66 | 100% | 50 | 50 | تانیر |
| 68 | 1.3.2.2.7 | **دیتاشیت‌ و اسپک** | 1d | 2026-04-30 A | 2026-04-30 A |  | 100% | 150 | 150 |  |
| 69 | 1.3.2.2.7.1 | پمپ‌ها | 1d | 2026-04-30 A | 2026-04-30 A | 67 | 100% | 50 | 50 | تانیر |
| 70 | 1.3.2.2.7.2 | مولد | 1d | 2026-04-30 A | 2026-04-30 A | 67 | 100% | 50 | 50 | تانیر |
| 71 | 1.3.2.2.7.3 | سیستم خنک کاری (مولد و سالن) | 1d | 2026-04-30 A | 2026-04-30 A | 67 | 100% | 50 | 50 | تانیر |
| 72 | 1.3.2.2.8 | **مستندات بهره‌برداری** | 1d | 2026-04-28 A | 2026-04-28 A |  | 100% | 50 | 50 |  |
| 73 | 1.3.2.2.8.1 | دستورالعمل بهره‌برداری | 1d | 2026-04-28 A | 2026-04-28 A | 65 | 100% | 50 | 50 | تانیر |
| 74 | 1.3.2.3 | **مهندسی برق** | 32.9d | 2026-04-22 A | 2026-05-30 A |  | 100% | 1,240 | 1,240 |  |
| 75 | 1.3.2.3.1 | **سیستم قدرت** | 3.5d | 2026-05-03 A | 2026-05-06 A |  | 100% | 300 | 300 |  |
| 76 | 1.3.2.3.1.1 | دیتا شیت و اسپک ترانسفورماتور قدرت | 2d | 2026-05-03 A | 2026-05-04 A |  | 100% | 100 | 100 | تانیر |
| 77 | 1.3.2.3.1.2 | دیتا شیت و اسپک سوئیچگیر MV | 2d | 2026-05-04 A | 2026-05-06 A | 76 | 100% | 100 | 100 | تانیر |
| 78 | 1.3.2.3.1.3 | AUX دیتا شیت و اسپک | 1d | 2026-05-04 A | 2026-05-05 A | 76 | 100% | 50 | 50 | تانیر |
| 79 | 1.3.2.3.1.4 | تابلوهای توزیع LV دیتا شیت و اسپک | 1d | 2026-05-05 A | 2026-05-05 A | 78 | 100% | 50 | 50 | تانیر |
| 80 | 1.3.2.3.2 | **مطالعات سیستم قدرت** | 4d | 2026-05-05 A | 2026-05-09 A |  | 100% | 240 | 240 |  |
| 81 | 1.3.2.3.2.1 | مطالعات اتصال کوتاه | 2d | 2026-05-05 A | 2026-05-06 A | 76 | 100% | 90 | 90 | تانیر |
| 82 | 1.3.2.3.2.2 | مطالعات پخش بار | 1d | 2026-05-07 A | 2026-05-07 A | 81 | 100% | 50 | 50 | تانیر |
| 83 | 1.3.2.3.2.3 | مطالعات اتصال به شبکه | 1d | 2026-05-09 A | 2026-05-09 A | 81, 82 | 100% | 100 | 100 | تانیر |

| ID | WBS | Task | Duration | Start | Finish | Predecessors | Complete | Cost | Actual cost | Text16 |
| --- | --- | --- | --- | --- | --- | --- | --- | --- | --- | --- |
| 84 | 1.3.2.3.3 | **کابل‌کشی** | 4d | 2026-05-03 A | 2026-05-06 A |  | 100% | 200 | 200 |  |
| 85 | 1.3.2.3.3.1 | محاسبات سایز کابل | 1d | 2026-05-03 A | 2026-05-03 A |  | 100% | 50 | 50 | تانیر |
| 86 | 1.3.2.3.3.2 | لیست کابل‌ها | 1d | 2026-05-04 A | 2026-05-04 A | 85 | 100% | 50 | 50 | تانیر |
| 87 | 1.3.2.3.3.3 | طراحی سینی کابل | 1d | 2026-05-05 A | 2026-05-05 A | 86 | 100% | 50 | 50 | تانیر |
| 88 | 1.3.2.3.3.4 | کابل‌ها (MTO) و سینی ها | 1d | 2026-05-06 A | 2026-05-06 A | 86, 87 | 100% | 50 | 50 | تانیر |
| 89 | 1.3.2.3.4 | **ارت و روشنایی** | 32.4d | 2026-04-22 A | 2026-05-30 A |  | 100% | 100 | 100 |  |
| 90 | 1.3.2.3.4.1 | طراحی سیستم ارتینگ | 1d | 2026-05-28 A | 2026-05-30 A | 25, 28 | 100% | 50 | 50 | تانیر |
| 91 | 1.3.2.3.4.2 | طراحی روشنایی | 1d | 2026-04-22 A | 2026-04-22 A | 30, 32 | 100% | 50 | 50 | تانیر |
| 92 | 1.3.2.3.5 | **نقشه‌های برق** | 30.9d | 2026-04-22 A | 2026-05-27 A |  | 100% | 200 | 200 |  |
| 93 | 1.3.2.3.5.1 | تک‌خطی MV و LV و AUX | 1d | 2026-05-05 A | 2026-05-06 A | 77, 78 | 100% | 50 | 50 | تانیر |
| 94 | 1.3.2.3.5.2 | سیستم DC شارژر | 1d | 2026-05-06 A | 2026-05-07 A | 93 | 100% | 50 | 50 | تانیر |
| 95 | 1.3.2.3.5.3 | پلان تجهیزات برق | 1d | 2026-04-22 A | 2026-05-27 A | 32 | 100% | 50 | 50 | تانیر |
| 96 | 1.3.2.3.5.4 | آرایش تابلوها | 1d | 2026-04-23 A | 2026-04-23 A | 95 | 100% | 50 | 50 | تانیر |
| 97 | 1.3.2.3.6 | **سیستم اعلام و اطفاء حریق** | 27.9d | 2026-04-28 A | 2026-05-30 A |  | 100% | 200 | 200 |  |
| 98 | 1.3.2.3.6.1 | دیاگرام بلوکی | 1d | 2026-04-28 A | 2026-04-28 A | 65 | 100% | 50 | 50 | تانیر |
| 99 | 1.3.2.3.6.2 | دیاگرام لوپ | 1d | 2026-04-29 A | 2026-04-29 A | 98 | 100% | 50 | 50 | تانیر |
| 100 | 1.3.2.3.6.3 | جانمایی تجهیزات | 1d | 2026-05-27 A | 2026-05-28 A | 95 | 100% | 50 | 50 | تانیر |
| 101 | 1.3.2.3.6.4 | لیست تجهیزات | 1d | 2026-05-28 A | 2026-05-30 A | 99, 100 | 100% | 50 | 50 | تانیر |
| 102 | 1.3.2.4 | **ابزار دقیق و کنترل (I&C)** | 30.7d | 2026-04-22 A | 2026-05-27 A |  | 100% | 110 | 110 |  |
| 103 | 1.3.2.4.1 | **سیستم کنترل** | 3d | 2026-04-28 A | 2026-04-30 A |  | 100% | 50 | 50 |  |
| 104 | 1.3.2.4.1.1 | فلسفه کنترل | 1d | 2026-04-28 A | 2026-04-28 A | 65 | 100% | 20 | 20 | تانیر |
| 105 | 1.3.2.4.1.2 | لیست I/O | 1d | 2026-04-29 A | 2026-04-29 A | 104 | 100% | 20 | 20 | تانیر |
| 106 | 1.3.2.4.1.3 | طراحی RTU | 1d | 2026-04-30 A | 2026-04-30 A | 105 | 100% | 10 | 10 | تانیر |
| 107 | 1.3.2.4.2 | **ابزار دقیق** | 2d | 2026-04-30 A | 2026-05-02 A |  | 100% | 30 | 30 |  |
| 108 | 1.3.2.4.2.1 | دیتاشیت ولوهای کنترلی | 1d | 2026-04-30 A | 2026-04-30 A | 65, 67 | 100% | 10 | 10 | تانیر |
| 109 | 1.3.2.4.2.2 | لیست کابل‌های I&C | 1d | 2026-04-30 A | 2026-04-30 A | 105 | 100% | 10 | 10 | تانیر |
| 110 | 1.3.2.4.2.3 | دیتاشیت تجهیزات خاص | 1d | 2026-05-02 A | 2026-05-02 A | 106 | 100% | 10 | 10 | تانیر |

| ID | WBS | Task | Duration | Start | Finish | Predecessors | Complete | Actual start | Actual finish | Cost | Actual cost | Text16 |
| --- | --- | --- | --- | --- | --- | --- | --- | --- | --- | --- | --- | --- |
| 111 | 1.3.2.4.3 | **اتاق کنترل** | 30.7d | 2026-04-22 A | 2026-05-27 A |  | 100% |  |  | 10 | 10 |  |
| 112 | 1.3.2.4.3.1 | طراحی اتاق کنترل | 1d | 2026-04-22 A | 2026-05-27 A | 32 | 100% |  |  | 10 | 10 | تانیر |
| 113 | 1.3.2.4.4 | **یکپارچه‌سازی** | 5.2d | 2026-05-02 A | 2026-05-07 A |  | 100% |  |  | 20 | 20 |  |
| 114 | 1.3.2.4.4.1 | متره کابل‌های I&C | 1d | 2026-05-02 A | 2026-05-02 A | 109 | 100% |  |  | 10 | 10 | تانیر |
| 115 | 1.3.2.4.4.2 | ارتباط با برق | 1d | 2026-05-06 A | 2026-05-07 A | 93, 106 | 100% |  |  | 10 | 10 | تانیر |
| 116 | 1.2 | **تأمین تجهیزات (Procurement)** | 147d | 2026-01-03 A | 2026-06-22 A |  | 100% |  |  | 1,079,801.4 | 1,079,801.4 |  |
| 117 | 1.2.1 | **مولد گازسوز CAT CG170** | 48d | 2026-04-28 A | 2026-06-22 A |  | 100% |  |  | 946,400 | 946,400 |  |
| 118 | 1.2.1.1 | گشایش اعتبار و سفارش گذاری مولد | 25d | 2026-04-28 A | 2026-05-26 A | 42 | 100% |  |  | 236,600 | 236,600 | تانیر |
| 119 | 1.2.1.2 | فرآیند ساخت در کارخانه CAT | 17d | 2026-05-27 A | 2026-06-15 A | 118 | 100% |  |  | 236,600 | 236,600 | تانیر |
| 120 | 1.2.1.3 | **تست کارخانه ای (FAT) مولد و رادیاتور** | 1d | 2026-04-29 | 2026-04-30 | 119 | 100% | 2026-06-16 | 2026-06-22 | 236,600 | 236,600 |  |
| 121 | 1.2.1.3.1 | آماده سازی برای تست کارخانه ای (FAT) مولد و رادیاتور | 3d | 2026-06-16 A | 2026-06-18 A | 119 | 100% |  |  | 236,600 | 236,600 | تانیر |
| 122 | 1.2.1.3.2 | اجرای نهایی و بازرسی تست کارخانه ای (FAT) مولد و رادیاتور | 3d | 2026-06-20 A | 2026-06-22 A | 121 | 100% |  |  |  |  | تانیر |
| 123 | 1.2.1.4 | حمل بین المللی و ترخیص گمرکی | 6d | 2026-05-02 A | 2026-05-07 A | 120 | 100% |  |  | 236,600 | 236,600 | تانیر |
| 124 | 1.2.1.5 | تخلیه و انبارش در سایت | 1d | 2026-05-09 A | 2026-05-09 A | 123 | 100% |  |  |  |  | تانیر |
| 125 | 1.2.2 | **تجهیزات جانبی مولد (Tool kit/Batteries)** | 35d | 2026-04-28 A | 2026-06-07 A |  | 100% |  |  | 4,422 | 4,422 |  |
| 126 | 1.2.2.1 | تأمین Tool Kit مخصوص کارخانه | 1d | 2026-04-28 A | 2026-04-28 A | 42 | 100% |  |  | 1,000 | 1,000 | تانیر |
| 127 | 1.2.2.2 | تأمین باتری ها و شارژرها | 10d | 2026-05-27 A | 2026-06-07 A | 118 | 100% |  |  | 2,600 | 2,600 | تانیر |
| 128 | 1.2.2.3 | تأمین متعلقات نصب و راه اندازی | 10d | 2026-05-27 A | 2026-06-07 A | 118 | 100% |  |  | 822 | 822 | تانیر |
| 129 | 1.2.3 | **تأمین سیستم های مکانیکی** | 127d | 2026-01-03 A | 2026-05-30 A |  | 100% |  |  | 54,792.9 | 54,792.9 |  |
| 130 | 1.2.3.1 | تأمین تجهیزات (داکت) ورودی هوای احتراق | 3d | 2026-05-02 A | 2026-05-04 A | 71 | 100% |  |  | 3,644.2 | 3,644.2 | تانیر |
| 131 | 1.2.3.2 | ساخت و تأمین اجزای دودکش و سایلنسر | 3d | 2026-05-05 A | 2026-05-07 A | 130 | 100% |  |  | 9,631.1 | 9,631.1 | تانیر |
| 132 | 1.2.3.3 | تأمین لوله و اتصالات گاز (Gas Train) | 1d | 2026-05-09 A | 2026-05-09 A | 131 | 100% |  |  | 3,644.2 | 3,644.2 | تانیر |
| 133 | 1.2.3.4 | تأمین کولر خنک کن هوایی (Radiator) | 1d | 2026-05-10 A | 2026-05-10 A | 132 | 100% |  |  | 3,904.5 | 3,904.5 | تانیر |
| 134 | 1.4.3.5 | تامین فن های ورودی / خروجی | 1d | 2026-01-03 A | 2026-01-03 A |  | 100% |  |  | 16,919.5 | 16,919.5 | تانیر |
| 135 | 1.4.3.6 | تامین عایق و رنگ | 1d | 2026-01-04 A | 2026-01-04 A | 134 | 100% |  |  | 2,733.15 | 2,733.15 | تانیر |

| ID | WBS | Task | Duration | Start | Finish | Predecessors | Complete | Cost | Actual cost | Text16 |
| --- | --- | --- | --- | --- | --- | --- | --- | --- | --- | --- |
| 136 | 1.2.3.5 | **تأمین پمپ ها و تجهیزات روغنکاری** | 20d | 2026-05-03 A | 2026-05-25 A |  | 100% | 14,316.25 | 14,316.25 |  |
| 137 | 1.4.3.7.1 | LT Oil Feed | 5d | 2026-05-03 A | 2026-05-07 A | 47 | 100% | 3,579.25 | 3,579.25 | تانیر |
| 138 | 1.4.3.7.2 | HT Oil Feed | 5d | 2026-05-09 A | 2026-05-13 A | 137 | 100% | 3,579 | 3,579 | تانیر |
| 139 | 1.4.3.7.3 | Feed Water | 5d | 2026-05-14 A | 2026-05-19 A | 138 | 100% | 3,579 | 3,579 | تانیر |
| 140 | 1.4.3.7.4 | (Utility / Service / Cooling) | 5d | 2026-05-20 A | 2026-05-25 A | 139 | 100% | 3,579 | 3,579 | تانیر |
| 141 | 1.2.3.6 | تأمین فن ها و دمپرهای تهویه سالن | 4d | 2026-05-26 A | 2026-05-30 A | 136 | 100% |  |  | تانیر |
| 142 | 1.2.4 | **تأمین تجهیزات برقی و کنترل** | 13d | 2026-05-09 A | 2026-05-23 A |  | 100% | 74,186.5 | 74,186.5 |  |
| 143 | 1.2.4.1 | ساخت تابلوهای مصرف داخلی (Aux) | 3d | 2026-05-09 A | 2026-05-11 A |  | 100% | 6,507.5 | 6,507.5 | تانیر |
| 144 | 1.2.4.2 | تأمین سوئیچگیر MV | 3d | 2026-05-12 A | 2026-05-14 A | 143 | 100% | 32,537.5 | 32,537.5 | تانیر |
| 145 | 1.2.4.3 | خرید کابل های MV و LV | 1d | 2026-05-16 A | 2026-05-16 A | 144 | 100% | 7,809 | 7,809 | تانیر |
| 146 | 1.4.4.4 | سیستم زمین (ارتینگ ثانویه) | 1d | 2026-05-17 A | 2026-05-17 A | 145 | 100% | 1,952.25 | 1,952.25 | تانیر |
| 147 | 1.2.4.4 | تأمین سینی کابل و کاندوئیت ها | 1d | 2026-05-17 A | 2026-05-17 A | 145 | 100% | 2,603 | 2,603 | تانیر |
| 148 | 1.2.4.5 | تأمین تجهیزات ابزاردقیق و مانیتورینگ | 1d | 2026-05-18 A | 2026-05-18 A | 147 | 100% | 9,110.5 | 9,110.5 | تانیر |
| 149 | 1.4.4.7 | تامین تابلو gcp | 1d | 2026-05-18 A | 2026-05-18 A | 146 | 100% | 1 | 1 | تانیر |
| 150 | 1.4.4.8 | تأمین Bulk Material | 3d | 2026-05-19 A | 2026-05-21 A | 149 | 100% | 1,952.25 | 1,952.25 | تانیر |
| 151 | 1.2.4.6 | تأمین سیستم Gas Detection | 4d | 2026-05-19 A | 2026-05-23 A | 148 | 100% | 11,713.5 | 11,713.5 | تانیر |
| 152 | 1.3 | **عملیات اجرایی (Construction)** | 62d | 2026-04-25 A | 2026-07-05 A |  | 100% | 14,000 | 14,000 |  |
| 153 | 1.3.1 | **عملیات سیویل و آماده سازی** | 50d | 2026-04-25 A | 2026-06-21 A |  | 100% | 6,498 | 6,498 |  |
| 154 | 1.3.1.1 | **خاکبرداری و تسطیح محل نصب** | 26d | 2026-04-25 A | 2026-05-24 A |  | 100% | 282 | 282 |  |
| 155 | 1.3.1.1.1 | آماده سازی برای خاکبرداری و تسطیح محل نصب | 1d | 2026-04-25 A | 2026-04-25 A |  | 100% | 141 | 141 | شرکت تأمین آب و انرژی هرمز ابدال |
| 156 | 1.3.1.1.2 | اجرای نهایی و بازرسی خاکبرداری و تسطیح محل نصب | 1d | 2026-05-24 A | 2026-05-24 A | 155, 151 | 100% | 141 | 141 | شرکت تأمین آب و انرژی هرمز ابدال |
| 157 | 1.3.1.2 | **فونداسیون‌ها و سازه‌های تجهیزات خاص** | 23d | 2026-05-24 A | 2026-06-18 A |  | 100% | 4,806 | 4,806 |  |
| 158 | 1.3.1.2.1 | فونداسیون و سازه رادیاتور | 9d | 2026-05-25 A | 2026-06-03 A | 154, 151 | 100% | 1,413 | 1,413 | شرکت تأمین آب و انرژی هرمز ابدال |
| 159 | 1.5.1.2.2 | فونداسیون و سازه مافلر | 9d | 2026-05-24 A | 2026-06-02 A | 151 | 100% | 1,131 | 1,131 | شرکت تأمین آب و انرژی هرمز ابدال |
| 160 | 1.5.1.2.3 | فونداسیون مخزن آب میک‌آپ | 9d | 2026-06-01 A | 2026-06-10 A | 159, 151 | 100% | 1,131 | 1,131 | شرکت تأمین آب و انرژی هرمز ابدال |
| 161 | 1.5.1.2.4 | فونداسیون مخزن روغن ترانسفورماتور | 9d | 2026-06-09 A | 2026-06-18 A | 160, 151 | 100% | 1,131 | 1,131 | شرکت تأمین آب و انرژی هرمز ابدال |

| ID | WBS | Task | Duration | Start | Finish | Predecessors | Complete | Cost | Actual cost | Text16 |
| --- | --- | --- | --- | --- | --- | --- | --- | --- | --- | --- |
| 162 | 1.3.1.3 | **عملیات تخریب و اصلاح سازه موجود** | 21.5d | 2026-05-26 A | 2026-06-20 A |  | 100% | 705 | 705 |  |
| 163 | 1.3.1.3.1 | بررسی وضعیت شلتر و سقف موجود | 1d | 2026-06-17 A | 2026-06-20 A | 157, 151 | 100% | 141 | 141 | شرکت تأمین آب و انرژی هرمز ابدال |
| 164 | 1.5.1.3.2 | ایمن‌سازی و آماده‌سازی محل کار | 1d | 2026-05-26 A | 2026-05-26 A | 140 | 100% | 141 | 141 | شرکت تأمین آب و انرژی هرمز ابدال |
| 165 | 1.5.1.3.3 | باز کردن و جمع‌آوری سقف شلتر موجود | 1d | 2026-05-27 A | 2026-05-27 A | 164, 151 | 100% | 141 | 141 | شرکت تأمین آب و انرژی هرمز ابدال |
| 166 | 1.5.1.3.4 | حمل و جمع‌آوری مصالح سقف قبلی | 1d | 2026-05-28 A | 2026-05-28 A | 165 | 100% | 141 | 141 | شرکت تأمین آب و انرژی هرمز ابدال |
| 167 | 1.5.1.3.5 | کنترل سازه و آماده‌سازی برای اجرای سقف جدید | 1d | 2026-05-30 A | 2026-05-30 A | 166 | 100% | 141 | 141 | شرکت تأمین آب و انرژی هرمز ابدال |
| 168 | 1.3.1.4 | **اجرای سقف جدید و اصلاح معماری** | 23d | 2026-05-26 A | 2026-06-21 A |  | 100% | 705 | 705 |  |
| 169 | 1.5.1.4.1 | اجرای سقف مسطح موقت | 1d | 2026-05-26 A | 2026-05-26 A | 140 | 100% | 141 | 141 | تانیر |
| 170 | 1.5.1.4.2 | اجرای سازه نگهدارنده سقف نهایی | 1d | 2026-05-30 A | 2026-05-30 A | 169, 166 | 100% | 141 | 141 | تانیر |
| 171 | 1.5.1.4.3 | نصب شلتر سقف نهایی | 1d | 2026-05-31 A | 2026-05-31 A | 170, 166 | 100% | 141 | 141 | تانیر |
| 172 | 1.3.1.4.1 | آب‌بندی و عایق‌کاری سقف | 1d | 2026-06-20 A | 2026-06-20 A | 157, 166 | 100% | 141 | 141 | تانیر |
| 173 | 1.3.1.4.2 | تست بارگذاری و کنترل سازه سقف | 1d | 2026-06-21 A | 2026-06-21 A | 172, 166 | 100% | 141 | 141 | تانیر |
| 174 | 1.3.2 | **نصب تجهیزات مکانیکی** | 41d | 2026-05-10 A | 2026-06-25 A |  | 100% | 4,089 | 4,089 |  |
| 175 | 1.3.2.1 | **استقرار و تراز مولد روی فونداسیون** | 2d | 2026-06-17 A | 2026-06-18 A |  | 100% | 282 | 282 |  |
| 176 | 1.3.2.1.1 | آماده سازی برای استقرار و تراز مولد روی فونداسیون | 1d | 2026-06-17 A | 2026-06-17 A | 161 | 100% | 141 | 141 | تانیر |
| 177 | 1.3.2.1.2 | اجرای نهایی و بازرسی استقرار و تراز مولد روی فونداسیون | 1d | 2026-06-18 A | 2026-06-18 A | 176 | 100% | 141 | 141 | تانیر |
| 178 | 1.3.2.2 | **نصب رادیاتور و سیستم خنک کن** | 1d | 2026-06-20 A | 2026-06-20 A |  | 100% | 282 | 282 |  |
| 179 | 1.3.2.2.1 | آماده سازی برای نصب رادیاتور و سیستم خنک کن | 1d | 2026-06-20 A | 2026-06-20 A | 133, 175 | 100% | 141 | 141 | تانیر |
| 180 | 1.3.2.2.2 | اجرای نهایی و بازرسی نصب رادیاتور و سیستم خنک کن | 1d | 2026-06-20 A | 2026-06-20 A | 133, 175, 177 | 100% | 141 | 141 | تانیر |
| 181 | 1.3.2.3 | **نصب سیستم دودکش و سایلنسر** | 2d | 2026-06-20 A | 2026-06-21 A |  | 100% | 282 | 282 |  |
| 182 | 1.3.2.3.1 | آماده سازی برای نصب سیستم دودکش و سایلنسر | 1d | 2026-06-20 A | 2026-06-20 A | 131, 175, 177 | 100% | 141 | 141 | تانیر |
| 183 | 1.3.2.3.2 | اجرای نهایی و بازرسی نصب سیستم دودکش و سایلنسر | 1d | 2026-06-21 A | 2026-06-21 A | 182, 177 | 100% | 141 | 141 | تانیر |
| 184 | 1.5.2.4 | **اجرای پایپینگ مربوط به پمپ‌ها** | 22d | 2026-05-30 A | 2026-06-23 A |  | 100% | 1,551 | 1,551 |  |
| 185 | 1.5.2.4.1 | **آماده‌سازی نصب** | 22d | 2026-05-30 A | 2026-06-23 A |  | 100% | 423 | 423 |  |
| 186 | 1.5.2.4.1.1 | تحویل فونداسیون پمپ‌ها از سیویل | 1d | 2026-05-30 A | 2026-05-30 A | 166 | 100% | 141 | 141 | تانیر |
| 187 | 1.5.2.4.1.2 | چک‌لیست تراز و انکر بولت‌ها | 1d | 2026-06-22 A | 2026-06-22 A | 186, 183 | 100% | 141 | 141 | تانیر |
| 188 | 1.5.2.4.1.3 | آماده‌سازی محل نصب | 1d | 2026-06-23 A | 2026-06-23 A | 187, 186 | 100% | 141 | 141 | تانیر |

| ID | WBS | Task | Duration | Start | Finish | Predecessors | Complete | Cost | Actual cost | Text16 |
| --- | --- | --- | --- | --- | --- | --- | --- | --- | --- | --- |
| 189 | 1.5.2.4.2 | **نصب مکانیکی پمپ‌ها** | 4d | 2026-05-31 A | 2026-06-03 A |  | 100% | 564 | 564 |  |
| 190 | 1.5.2.4.2.1 | نصب پمپ LT Oil Feed | 1d | 2026-05-31 A | 2026-05-31 A | 186 | 100% | 141 | 141 | تانیر |
| 191 | 1.5.2.4.2.2 | نصب پمپ HT Oil Feed | 1d | 2026-06-01 A | 2026-06-01 A | 190, 186 | 100% | 141 | 141 | تانیر |
| 192 | 1.5.2.4.2.3 | نصب پمپ Feed Water | 1d | 2026-06-02 A | 2026-06-02 A | 191, 186 | 100% | 141 | 141 | تانیر |
| 193 | 1.5.2.4.2.4 | نصب سایر پمپ‌ها | 1d | 2026-06-03 A | 2026-06-03 A | 192, 186 | 100% | 141 | 141 | تانیر |
| 194 | 1.5.2.4.3 | **اجرای پایپینگ ورودی/خروجی پمپ‌ها** | 5d | 2026-06-04 A | 2026-06-09 A |  | 100% | 564 | 564 |  |
| 195 | 1.5.2.4.3.1 | suction پمپ‌ها oil | 1d | 2026-06-04 A | 2026-06-04 A | 189 | 100% | 141 | 141 | تانیر |
| 196 | 1.5.2.4.3.2 | discharge پمپ‌ها oil | 1d | 2026-06-06 A | 2026-06-06 A | 195 | 100% | 141 | 141 | تانیر |
| 197 | 1.5.2.4.3.3 | نصب ولوها و استرینرها | 1d | 2026-06-08 A | 2026-06-08 A | 196 | 100% | 141 | 141 | تانیر |
| 198 | 1.5.2.4.3.4 | نصب ساپورت‌های لوله | 1d | 2026-06-09 A | 2026-06-09 A | 197 | 100% | 141 | 141 | تانیر |
| 199 | 1.3.2.4 | **اجرای پایپینگ گاز و Gas Train** | 2d | 2026-05-10 A | 2026-05-11 A |  | 100% | 282 | 282 |  |
| 200 | 1.3.2.4.1 | آماده سازی برای اجرای پایپینگ گاز و Gas Train | 1d | 2026-05-10 A | 2026-05-10 A | 132 | 100% | 141 | 141 | تانیر |
| 201 | 1.3.2.4.2 | اجرای نهایی و بازرسی اجرای پایپینگ گاز و Gas Train | 1d | 2026-05-11 A | 2026-05-11 A | 200 | 100% | 141 | 141 | تانیر |
| 202 | 1.3.2.5 | **اجرای پایپینگ آب خنک کن** | 2d | 2026-06-21 A | 2026-06-22 A |  | 100% | 282 | 282 |  |
| 203 | 1.3.2.5.1 | آماده سازی برای اجرای پایپینگ آب خنک کن | 1d | 2026-06-21 A | 2026-06-21 A | 133, 178, 186 | 100% | 141 | 141 | تانیر |
| 204 | 1.3.2.5.2 | اجرای نهایی و بازرسی اجرای پایپینگ آب خنک کن | 1d | 2026-06-22 A | 2026-06-22 A | 203, 186 | 100% | 141 | 141 | تانیر |
| 205 | 1.3.2.6 | **نصب سیستم های روغنکاری و مخازن** | 2d | 2026-05-31 A | 2026-06-01 A |  | 100% | 282 | 282 |  |
| 206 | 1.3.2.6.1 | آماده سازی برای نصب سیستم های روغنکاری و مخازن | 1d | 2026-05-31 A | 2026-05-31 A | 186 | 100% | 141 | 141 | تانیر |
| 207 | 1.3.2.6.2 | اجرای نهایی و بازرسی نصب سیستم های روغنکاری و مخازن | 1d | 2026-06-01 A | 2026-06-01 A | 206 | 100% | 141 | 141 | تانیر |
| 208 | 1.3.2.7 | **نصب تجهیزات تهویه و فن های سالن** | 2d | 2026-05-31 A | 2026-06-01 A |  | 100% | 282 | 282 |  |
| 209 | 1.3.2.7.1 | آماده سازی برای نصب تجهیزات تهویه و فن های سالن | 1d | 2026-05-31 A | 2026-05-31 A | 186 | 100% | 141 | 141 | تانیر |
| 210 | 1.3.2.7.2 | اجرای نهایی و بازرسی نصب تجهیزات تهویه و فن های سالن | 1d | 2026-06-01 A | 2026-06-01 A | 209 | 100% | 141 | 141 | تانیر |
| 211 | 1.3.2.8 | **عایق کاری لوله های داغ و اگزوز** | 2d | 2026-06-22 A | 2026-06-23 A |  | 100% | 282 | 282 |  |
| 212 | 1.3.2.8.1 | آماده سازی برای عایق کاری لوله های داغ و اگزوز | 1d | 2026-06-22 A | 2026-06-22 A | 181, 186 | 100% | 141 | 141 | تانیر |
| 213 | 1.3.2.8.2 | اجرای نهایی و بازرسی عایق کاری لوله های داغ و اگزوز | 1d | 2026-06-23 A | 2026-06-23 A | 212, 186 | 100% | 141 | 141 | تانیر |

| ID | WBS | Task | Duration | Start | Finish | Predecessors | Complete | Cost | Actual cost | Text16 |
| --- | --- | --- | --- | --- | --- | --- | --- | --- | --- | --- |
| 214 | 1.3.2.9 | **رنگ آمیزی و پوشش نهایی تجهیزات** | 2d | 2026-06-24 A | 2026-06-25 A |  | 100% | 282 | 282 |  |
| 215 | 1.3.2.9.1 | آماده سازی برای رنگ آمیزی و پوشش نهایی تجهیزات | 1d | 2026-06-24 A | 2026-06-24 A | 211, 166 | 100% | 141 | 141 | تانیر |
| 216 | 1.3.2.9.2 | اجرای نهایی و بازرسی رنگ آمیزی و پوشش نهایی تجهیزات | 1d | 2026-06-25 A | 2026-06-25 A | 215, 166 | 100% | 141 | 141 | تانیر |
| 217 | 1.3.3 | **اجرای سیستم های برقی** | 8d | 2026-06-27 A | 2026-07-05 A |  | 100% | 2,822 | 2,822 |  |
| 218 | 1.3.3.1 | **اجرای شبکه زمین و ارتینگ ثانویه** | 2d | 2026-06-27 A | 2026-06-28 A |  | 100% | 282 | 282 |  |
| 219 | 1.3.3.1.1 | آماده سازی برای اجرای شبکه زمین و ارتینگ ثانویه | 1d | 2026-06-27 A | 2026-06-27 A | 216 | 100% | 141 | 141 | تانیر |
| 220 | 1.3.3.1.2 | اجرای نهایی و بازرسی اجرای شبکه زمین و ارتینگ ثانویه | 1d | 2026-06-28 A | 2026-06-28 A | 219 | 100% | 141 | 141 | تانیر |
| 221 | 1.3.3.2 | **نصب سینی کابل و نردبان کابل** | 2d | 2026-06-27 A | 2026-06-28 A |  | 100% | 282 | 282 |  |
| 222 | 1.3.3.2.1 | آماده سازی برای نصب سینی کابل و نردبان کابل | 1d | 2026-06-27 A | 2026-06-27 A | 216 | 100% | 141 | 141 | تانیر |
| 223 | 1.3.3.2.2 | اجرای نهایی و بازرسی نصب سینی کابل و نردبان کابل | 1d | 2026-06-28 A | 2026-06-28 A | 222 | 100% | 141 | 141 | تانیر |
| 224 | 1.3.3.3 | **نصب تابلوهای فشار متوسط (MV)** | 2d | 2026-06-27 A | 2026-06-28 A |  | 100% | 282 | 282 |  |
| 225 | 1.3.3.3.1 | آماده سازی برای نصب تابلوهای فشار متوسط (MV) | 1d | 2026-06-27 A | 2026-06-27 A | 216 | 100% | 141 | 141 | تانیر |
| 226 | 1.3.3.3.2 | اجرای نهایی و بازرسی نصب تابلوهای فشار متوسط (MV) | 1d | 2026-06-28 A | 2026-06-28 A | 225 | 100% | 141 | 141 | تانیر |
| 227 | 1.3.3.4 | **نصب تابلوهای فشار ضعیف و مصرف داخلی** | 2d | 2026-06-27 A | 2026-06-28 A |  | 100% | 848 | 848 |  |
| 228 | 1.3.3.4.1 | آماده سازی برای نصب تابلوهای فشار ضعیف و مصرف داخلی | 1d | 2026-06-27 A | 2026-06-27 A | 143, 216 | 100% | 424 | 424 | تانیر |
| 229 | 1.3.3.4.2 | اجرای نهایی و بازرسی نصب تابلوهای فشار ضعیف و مصرف داخلی | 1d | 2026-06-28 A | 2026-06-28 A | 228, 216 | 100% | 424 | 424 | تانیر |
| 230 | 1.3.3.5 | **کابل کشی قدرت (MV/LV)** | 4d | 2026-06-29 A | 2026-07-02 A |  | 100% | 564 | 564 |  |
| 231 | 1.3.3.5.1 | آماده سازی برای کابل کشی قدرت (MV/LV) | 1d | 2026-06-29 A | 2026-06-29 A | 229 | 100% | 141 | 141 | تانیر |
| 232 | 1.3.3.5.2 | اجرای نهایی و بازرسی کابل کشی قدرت (MV/LV) | 1d | 2026-06-30 A | 2026-06-30 A | 231 | 100% | 141 | 141 | تانیر |
| 233 | 1.5.3.5.3 | آماده سازی برای کابل کشی aux | 1d | 2026-07-01 A | 2026-07-01 A | 232 | 100% | 141 | 141 | تانیر |
| 234 | 1.5.3.5.4 | اجرای نهایی و بازرسی کابل کشی aux | 1d | 2026-07-02 A | 2026-07-02 A | 233 | 100% | 141 | 141 | تانیر |
| 235 | 1.3.3.6 | **کابل کشی کنترل و ابزاردقیق** | 2d | 2026-06-29 A | 2026-06-30 A |  | 100% | 282 | 282 |  |
| 236 | 1.3.3.6.1 | آماده سازی برای کابل کشی کنترل و ابزاردقیق | 1d | 2026-06-29 A | 2026-06-29 A | 221, 145, 229 | 100% | 141 | 141 | تانیر |
| 237 | 1.3.3.6.2 | اجرای نهایی و بازرسی کابل کشی کنترل و ابزاردقیق | 1d | 2026-06-30 A | 2026-06-30 A | 236, 229 | 100% | 141 | 141 | تانیر |

| ID | WBS | Task | Type | Duration | Start | Finish | Predecessors | Complete | Cost | Actual cost | Text16 |
| --- | --- | --- | --- | --- | --- | --- | --- | --- | --- | --- | --- |
| 238 | 1.3.3.7 | **سربندی (Termination) کابل ها** |  | 2d | 2026-07-04 A | 2026-07-05 A |  | 100% | 282 | 282 |  |
| 239 | 1.3.3.7.1 | آماده سازی برای سربندی (Termination) کابل ها |  | 1d | 2026-07-04 A | 2026-07-04 A | 230, 235, 229 | 100% | 141 | 141 | تانیر |
| 240 | 1.3.3.7.2 | اجرای نهایی و بازرسی سربندی (Termination) کابل ها |  | 1d | 2026-07-05 A | 2026-07-05 A | 239, 229 | 100% | 141 | 141 | تانیر |
| 241 | 1.3.4 | **نصب ابزاردقیق و کنترل** |  | 1d | 2026-06-27 A | 2026-06-27 A |  | 100% | 591 | 591 |  |
| 242 | 1.3.4.1 | **نصب تجهیزات مانیتورینگ موتور** |  | 1d | 2026-06-27 A | 2026-06-27 A |  | 100% | 282 | 282 |  |
| 243 | 1.3.4.1.1 | آماده سازی برای نصب تجهیزات مانیتورینگ موتور |  | 1d | 2026-06-27 A | 2026-06-27 A | 175, 216 | 100% | 141 | 141 | تانیر |
| 244 | 1.3.4.1.2 | اجرای نهایی و بازرسی نصب تجهیزات مانیتورینگ موتور | milestone | 0d | 2026-06-27 A | 2026-06-27 A | 243, 216 | 100% | 141 | 141 | تانیر |
| 245 | 1.3.4.2 | **نصب سنسورها و تجهیزات فیلد** |  | 1d | 2026-06-27 A | 2026-06-27 A |  | 100% | 141 | 141 |  |
| 246 | 1.3.4.2.1 | آماده سازی برای نصب سنسورها و تجهیزات فیلد |  | 1d | 2026-06-27 A | 2026-06-27 A | 199, 202, 216 | 100% | 141 | 141 | تانیر |
| 247 | 1.3.4.2.2 | اجرای نهایی و بازرسی نصب سنسورها و تجهیزات فیلد | milestone | 0d | 2026-06-27 A | 2026-06-27 A | 246, 216 | 100% |  |  | تانیر |
| 248 | 1.3.4.3 | **نصب سیستم Gas Detection** |  | 1d | 2026-06-27 A | 2026-06-27 A |  | 100% | 141 | 141 |  |
| 249 | 1.3.4.3.1 | آماده سازی برای نصب سیستم Gas Detection |  | 1d | 2026-06-27 A | 2026-06-27 A | 199, 216 | 100% | 141 | 141 | تانیر |
| 250 | 1.3.4.3.2 | اجرای نهایی و بازرسی نصب سیستم Gas Detection | milestone | 0d | 2026-06-27 A | 2026-06-27 A | 249, 216 | 100% |  |  | تانیر |
| 251 | 1.3.4.4 | **نصب و پیکربندی سیستم کنترل مرکزی** |  | 1d | 2026-06-27 A | 2026-06-27 A |  | 100% | 27 | 27 |  |
| 252 | 1.3.4.4.1 | آماده سازی برای نصب و پیکربندی سیستم کنترل مرکزی |  | 1d | 2026-06-27 A | 2026-06-27 A | 148, 216 | 100% |  |  | تانیر |
| 253 | 1.3.4.4.2 | اجرای نهایی و بازرسی نصب و پیکربندی سیستم کنترل مرکزی | milestone | 0d | 2026-06-27 A | 2026-06-27 A | 252, 216 | 100% | 27 | 27 | تانیر |
| 254 | 1.4 | **تست و راه اندازی (Commissioning)** |  | 5d | 2026-07-06 A | 2026-07-11 A |  | 100% | 1,000 | 1,000 |  |
| 255 | 1.4.1 | **تست های پیش راه اندازی (Pre-Comm)** |  | 4d | 2026-07-06 A | 2026-07-09 A |  | 100% | 84 | 84 |  |
| 256 | 1.4.1.1 | چک‌لیست‌های نصب تجهیزات |  | 4d | 2026-07-06 A | 2026-07-09 A | 152 | 100% | 21 | 21 | تانیر |
| 257 | 1.4.1.2 | تست عایقی و پیوستگی کابل ها |  | 4d | 2026-07-06 A | 2026-07-09 A | 152 | 100% | 42 | 42 | تانیر |
| 258 | 1.6.1.3 | تمیزکاری و فلاشینگ سیستم‌ها |  | 4d | 2026-07-06 A | 2026-07-09 A | 152 | 100% | 21 | 21 | تانیر |
| 259 | 1.6.2 | **تست ترانسفورماتور** |  | 4d | 2026-07-06 A | 2026-07-09 A |  | 100% | 105 | 105 |  |
| 260 | 1.6.2.1 | تست نسبت تبدیل (TTR Test) |  | 4d | 2026-07-06 A | 2026-07-09 A | 152 | 100% | 21 | 21 | تانیر |
| 261 | 1.6.2.2 | تست عایقی (IR / Megger Test) |  | 4d | 2026-07-06 A | 2026-07-09 A | 152 | 100% | 21 | 21 | تانیر |
| 262 | 1.6.2.3 | تست روغن ترانس (BDV & DGA) |  | 4d | 2026-07-06 A | 2026-07-09 A | 152 | 100% | 21 | 21 | تانیر |
| 263 | 1.6.2.4 | تست عملکرد بی‌بار (No Load Test) |  | 4d | 2026-07-06 A | 2026-07-09 A | 152 | 100% | 21 | 21 | تانیر |
| 264 | 1.6.2.5 | تست تحت بار (Load Test) |  | 4d | 2026-07-06 A | 2026-07-09 A | 152 | 100% | 21 | 21 | تانیر |

| ID | WBS | Task | Duration | Start | Finish | Predecessors | Complete | Cost | Actual cost | Text16 |
| --- | --- | --- | --- | --- | --- | --- | --- | --- | --- | --- |
| 265 | 1.6.3 | **تست ژنراتور / مولد** | 4d | 2026-07-06 A | 2026-07-09 A |  | 100% | 148 | 148 |  |
| 266 | 1.6.3.1 | تست عایقی ژنراتور | 4d | 2026-07-06 A | 2026-07-09 A | 152 | 100% | 21 | 21 | تانیر |
| 267 | 1.6.3.2 | تست مدار تحریک | 4d | 2026-07-06 A | 2026-07-09 A | 152 | 100% | 21 | 21 | تانیر |
| 268 | 1.6.3.3 | تست سنکرونیزاسیون | 4d | 2026-07-06 A | 2026-07-09 A | 152 | 100% | 21 | 21 | تانیر |
| 269 | 1.6.3.4 | تست بی‌بار | 4d | 2026-07-06 A | 2026-07-09 A | 152 | 100% | 21 | 21 | تانیر |
| 270 | 1.6.3.5 | تست تحت بار کامل (Full Load Test) | 4d | 2026-07-06 A | 2026-07-09 A | 152 | 100% | 21 | 21 | تانیر |
| 271 | 1.6.3.6 | تست حفاظت‌ها (Protection Test) | 4d | 2026-07-06 A | 2026-07-09 A | 152 | 100% | 43 | 43 | تانیر |
| 272 | 1.6.4 | **تست رادیاتور و سیستم خنک‌کاری** | 4d | 2026-07-06 A | 2026-07-09 A |  | 100% | 105 | 105 |  |
| 273 | 1.6.4.1 | تست فشار (Pressure Test) | 4d | 2026-07-06 A | 2026-07-09 A | 152 | 100% | 21 | 21 | تانیر |
| 274 | 1.6.4.2 | تست نشتی (Leak Test) | 4d | 2026-07-06 A | 2026-07-09 A | 152 | 100% | 21 | 21 | تانیر |
| 275 | 1.6.4.3 | تست عملکرد فن‌ها | 4d | 2026-07-06 A | 2026-07-09 A | 152 | 100% | 21 | 21 | تانیر |
| 276 | 1.6.4.4 | تست گردش سیال خنک‌کننده | 4d | 2026-07-06 A | 2026-07-09 A | 152 | 100% | 21 | 21 | تانیر |
| 277 | 1.6.4.5 | تست عملکرد در بار نامی | 4d | 2026-07-06 A | 2026-07-09 A | 152 | 100% | 21 | 21 | تانیر |
| 278 | 1.6.5 | **تست سوئیچگیر (MV / LV Switchgear)** | 4d | 2026-07-06 A | 2026-07-09 A |  | 100% | 147 | 147 |  |
| 279 | 1.6.5.1 | تست عایقی (IR Test) | 4d | 2026-07-06 A | 2026-07-09 A | 152 | 100% | 21 | 21 | تانیر |
| 280 | 1.6.5.2 | تست عملکرد بریکرها | 4d | 2026-07-06 A | 2026-07-09 A | 152 | 100% | 21 | 21 | تانیر |
| 281 | 1.6.5.3 | تست اینترلاک‌ها | 4d | 2026-07-06 A | 2026-07-09 A | 152 | 100% | 21 | 21 | تانیر |
| 282 | 1.6.5.4 | تست رله‌های حفاظتی | 4d | 2026-07-06 A | 2026-07-09 A | 152 | 100% | 21 | 21 | تانیر |
| 283 | 1.6.5.5 | تست قطع و وصل تحت بار | 4d | 2026-07-06 A | 2026-07-09 A | 152 | 100% | 21 | 21 | تانیر |
| 284 | 1.6.5.6 | تست هماهنگی حفاظتی | 4d | 2026-07-06 A | 2026-07-09 A | 152 | 100% | 21 | 21 | تانیر |
| 285 | 1.6.5.7 | تست تابلو gcp و aux | 4d | 2026-07-06 A | 2026-07-09 A | 152 | 100% | 21 | 21 | تانیر |
| 286 | 1.6.6 | **تست سیستم کولینگ (Cooling System) سالن موتور** | 4d | 2026-07-06 A | 2026-07-09 A |  | 100% | 105 | 105 |  |
| 287 | 1.6.6.1 | تست پمپ‌های سیستم خنک‌کاری | 4d | 2026-07-06 A | 2026-07-09 A | 152 | 100% | 21 | 21 | تانیر |
| 288 | 1.6.6.2 | تست مدار لوله‌کشی خنک‌کاری | 4d | 2026-07-06 A | 2026-07-09 A | 152 | 100% | 21 | 21 | تانیر |
| 289 | 1.6.6.3 | تست عملکرد مبدل‌های حرارتی | 4d | 2026-07-06 A | 2026-07-09 A | 152 | 100% | 21 | 21 | تانیر |
| 290 | 1.6.6.4 | تست دبی و فشار سیستم | 4d | 2026-07-06 A | 2026-07-09 A | 152 | 100% | 21 | 21 | تانیر |
| 291 | 1.6.6.5 | تست عملکرد در شرایط عملیاتی | 4d | 2026-07-06 A | 2026-07-09 A | 152 | 100% | 21 | 21 | تانیر |

| ID | WBS | Task | Type | Duration | Start | Finish | Predecessors | Complete | Remaining | Total slack | Cost | Actual cost | Text16 |
| --- | --- | --- | --- | --- | --- | --- | --- | --- | --- | --- | --- | --- | --- |
| 292 | 1.6.7 | **تست‌های یکپارچه (Integrated Tests)** |  | 4d | 2026-07-06 A | 2026-07-09 A |  | 100% |  |  | 105 | 105 |  |
| 293 | 1.6.7.1 | تست بدون بار کل واحد (No Load Test Run) |  | 4d | 2026-07-06 A | 2026-07-09 A | 152 | 100% |  |  | 21 | 21 | تانیر |
| 294 | 1.6.7.2 | تست سنکرون کل سیستم |  | 4d | 2026-07-06 A | 2026-07-09 A | 152 | 100% |  |  | 21 | 21 | تانیر |
| 295 | 1.6.7.3 | تست Load Acceptance |  | 4d | 2026-07-06 A | 2026-07-09 A | 152 | 100% |  |  | 21 | 21 | تانیر |
| 296 | 1.6.7.4 | تست Trip و Emergency Shutdown |  | 4d | 2026-07-06 A | 2026-07-09 A | 152 | 100% |  |  | 21 | 21 | تانیر |
| 297 | 1.6.7.5 | تست عملکرد سیستم‌های کمکی |  | 4d | 2026-07-06 A | 2026-07-09 A | 152 | 100% |  |  | 21 | 21 | تانیر |
| 298 | 1.4.1.3 | **Cold Loop Test ابزاردقیق** |  | 1d | 2026-07-06 A | 2026-07-06 A |  | 100% |  |  | 42 | 42 |  |
| 299 | 1.4.1.3.1 | آماده سازی برای Cold Loop Test ابزاردقیق |  | 1d | 2026-07-06 A | 2026-07-06 A | 152 | 100% |  |  | 21 | 21 | تانیر |
| 300 | 1.4.1.3.2 | اجرای نهایی و بازرسی Cold Loop Test ابزاردقیق |  | 1d | 2026-07-06 A | 2026-07-06 A | 152 | 100% |  |  | 21 | 21 | تانیر |
| 301 | 1.4.2 | **راه اندازی (Commissioning)** |  | 1d | 2026-07-11 A | 2026-07-11 A |  | 100% |  |  | 159 | 159 |  |
| 302 | 1.4.2.1 | برق دار کردن تابلوهای داخلی |  | 1d | 2026-07-11 A | 2026-07-11 A | 257, 288 | 100% |  |  | 21 | 21 | تانیر |
| 303 | 1.4.2.2 | تست عملکردی سیستم سوخت رسانی |  | 1d | 2026-07-11 A | 2026-07-11 A | 302SS | 100% |  |  | 21 | 21 | تانیر |
| 304 | 1.4.2.3 | استارت اولیه مولد بدون بار |  | 1d | 2026-07-11 A | 2026-07-11 A | 302SS | 100% |  |  | 21 | 21 | تانیر |
| 305 | 1.4.2.4 | تست پارالل و سنکرون سازی |  | 1d | 2026-07-11 A | 2026-07-11 A | 302SS | 100% |  |  | 21 | 21 | تانیر |
| 306 | 1.4.2.5 | تست عملکردی زیر بار (Load Test) |  | 1d | 2026-07-11 A | 2026-07-11 A | 302SS | 100% |  |  | 33 | 33 | تانیر |
| 307 | 1.4.2.6 | تست نهایی سیستم Gas Detection |  | 1d | 2026-07-11 A | 2026-07-11 A | 302SS | 100% |  |  | 42 | 42 | تانیر |
| 308 | 1.5 | **تحویل و بهره برداری (Close-out)** |  | 30d | 2026-07-12 A | 2026-08-15 |  | 27% | 22d | 0d | 15,000 | 1,000 |  |
| 309 | 1.5.1 | **بهره برداری آزمایشی** |  | 17d | 2026-07-12 A | 2026-07-30 |  | 47% | 9d | 0d | 1,000 | 1,000 |  |
| 310 | 1.5.1.1 | دوره 72 ساعته تست مداوم |  | 1d | 2026-07-12 A | 2026-07-12 A | 254 | 100% |  |  | 1,000 | 1,000 | شرکت تأمین آب و انرژی هرمز ابدال |
| 311 | 1.5.1.2 | رفع نواقص احتمالی (Punch List) |  | 16d | 2026-07-13 A | 2026-07-30 | 310 | 44% | 9d | 0d |  |  | تانیر |
| 312 | 1.5.2 | **مستندات و تحویل** |  | 13d | 2026-08-01 | 2026-08-15 |  |  |  | 0d | 14,000 |  |  |
| 313 | 1.5.2.1 | تهیه نقشه های As-Built |  | 2d | 2026-08-01 | 2026-08-02 | 311 |  |  | 0d | 2,000 |  | تانیر |
| 314 | 1.5.2.2 | آموزش تیم بهره بردار کارفرما |  | 3d | 2026-08-03 | 2026-08-05 | 313 |  |  | 0d | 1,000 |  | شرکت تأمین آب و انرژی هرمز ابدال |
| 315 | 1.5.2.3 | تحویل موقت (PAC) |  | 7d | 2026-08-06 | 2026-08-13 | 314 |  |  | 0d | 1,000 |  | شرکت افق تأمین انرژی پارس |
| 316 | 1.5.2.4 | شروع دوره بهره برداری (Operation) |  | 1d | 2026-08-15 | 2026-08-15 | 315 |  |  | 0d | 10,000 |  | شرکت افق تأمین انرژی پارس |
| 317 | 1.8 | پایان | milestone | 0d | 2026-08-15 | 2026-08-15 | 316, 297, 300, 291, 284, 277, 271, 94, 36, 50 |  |  | 0d |  |  |  |
